# SERVICIO DE HABILITACIÓN DE ACCESOS Y PLATAFORMAS, Y MOVIMIENTO DE TIERRAS II PARTE - CUENCA CAÑETE

Schedule from Primavera P6, 2023-03-10 to 2024-02-03, data date 2023-03-10.

## Calendars

- Dos turnos - 6x1 - 10 horas: Mon-Sat 01:00-06:00, 07:00-12:00, 13:00-18:00, 19:00-00:00; Sun off. Exceptions (off unless hours are given): 2023-04-06 to 2023-04-07, 2023-05-01, 2023-06-29, 2023-07-28 to 2023-07-29, 2023-08-30, 2023-11-01, 2023-12-08, 2023-12-25, 2024-01-01.

## Schedule

| ID | WBS | Activity | Type | Duration | Start | Finish | Predecessors | Total float | Free float |
| --- | --- | --- | --- | --- | --- | --- | --- | --- | --- |
|  | 1 | **Hitos** |  |  | 2023-03-10 | 2024-01-27 |  |  |  |
| A1000 |  | Suscripción del contrato | milestone | 0d | 2023-03-10 | 2023-03-10 |  | 0d |  |
| A1010 |  | Inicio de obra - Acceso al Sitio | milestone | 0d | 2023-04-01 | 2023-04-01 | A1000 FS+19d | 0d |  |
| A1020 |  | Inicio de Habilitación y mejoramiento de accesos | milestone | 0d | 2023-04-11 | 2023-04-11 | A1160 SS+3d | 0d |  |
| A1030 |  | Inicio de Movimiento de Tierras - Diques Paquete 2 | milestone | 0d | 2023-04-21 | 2023-04-21 | A1130 SS+6d | 122d | 0d |
| A1050 |  | Inicio de Movimiento de Tierras - Diques Paquete 3 | milestone | 0d | 2023-07-01 | 2023-07-01 | A1010 FS+74d, A2788 | 0d |  |
| A1040 |  | Culminación de Diques Paquete 2 | milestone | 0d | 2023-08-01 | 2023-08-01 | A1190, A1200, A1210, A1220, A1230, A1240, A1250, A1260, A1280, A1290, A2320 | 149d |  |
| A1060 |  | Culminación de Diques Paquete 3 | milestone | 0d | 2024-01-27 | 2024-01-27 | A1320, A1330, A1340, A1350, A1380, A1400, A1410, A1440, A1450, A1460, A1470, A1500, A1520, A1530, A1550, A1560, A1570, A1600, A1610, A1620, A1630, A1660, A1680, A1690, A1720, A1730, A1740, A1750, A1780, A1800, A1810, A1960, A1970, A1980, A1990, A2020, A2040, A2050, A1840, A1860, A2080, A2090, A2100, A2110, A2140, A2160, A2170, A2200, A2210, A2220, A2230, A2260, A2280, A2290, A1315, A1435, A1595, A2010, A2788, A2830, A1900, A2000, A2310, A1850, A2660 | 0d |  |
|  | 2 | **Obras Provisionales** |  |  | 2023-04-01 | 2024-02-03 |  |  |  |
| A1070 |  | Movilización |  | 26d | 2023-04-01 | 2023-05-05 | A1010 | 0d |  |
| A1080 |  | Mejoramiento y habilitación de caminos de acceso |  | 112d | 2023-04-11 | 2023-08-24 | A1020 | 0d |  |
| A1090 |  | Limpieza manual de material vegetal y de residuos |  | 32d | 2023-04-11 | 2023-05-19 | A1080 SS | 209d |  |
| A1120 |  | Habilitación de plataformas |  | 26d | 2023-04-14 | 2023-05-16 | A1130 SS | 212d |  |
| A1130 |  | Campamento Provisional de Obra |  | 26d | 2023-04-14 | 2023-05-16 | A1080 SS+3d | 122d | 0d |
| A1140 |  | Mantenimiento de caminos de acceso |  | 235d | 2023-04-14 | 2024-01-24 | A1080 SS+3d | 3d |  |
| A1150 |  | Desmovilización |  | 6d | 2024-01-27 | 2024-02-03 | A1140, A1060, A2300, A1090, A1120, A1040 | 0d |  |
|  | 1 | **Cruces y accesos sobre río** |  |  | 2023-05-10 | 2023-07-01 |  |  |  |
| A2784 |  | Cruce La Florida |  | 20d | 2023-05-10 | 2023-06-02 | A1080 SS+24d | 0d |  |
| A2785 |  | Cruce Con Con |  | 20d | 2023-05-24 | 2023-06-16 | A2784 SS+12d | 0d |  |
| A2788 |  | Cruce Ramadilla |  | 20d | 2023-06-07 | 2023-07-01 | A2785 SS+12d | 0d |  |
|  | 3 | **Topografía** |  |  | 2023-04-05 | 2023-05-09 |  |  |  |
| A1160 |  | Trazo y replanteo inicial |  | 26d | 2023-04-05 | 2023-05-09 | A1070 SS+3d | 0d |  |
|  | 4 | **Paquete 2** |  |  | 2023-04-21 | 2023-08-01 |  |  |  |
|  | 1 | **DE-PR-07-I** |  |  | 2023-04-21 | 2023-08-01 |  |  |  |
|  | 1 | **Excavaciones** |  |  | 2023-04-21 | 2023-06-11 |  |  |  |
| A1190 |  | Excavación - desbroce + cimentación |  | 36d | 2023-04-21 | 2023-06-03 | A1030 | 122d | 0d |
| A1200 |  | Perfilado y conformación de plataforma de fundación |  | 36d | 2023-04-28 | 2023-06-10 | A1190 SS+6d | 122d | 0d |
| A1210 |  | Excavación de uña |  | 34d | 2023-05-03 | 2023-06-11 | A1200 SS+3d | 122d | 0d |

| ID | WBS | Activity | Duration | Start | Finish | Predecessors | Total float | Free float |
| --- | --- | --- | --- | --- | --- | --- | --- | --- |
|  | 2 | **Cuerpo del Dique** |  | 2023-05-06 | 2023-06-28 |  |  |  |
| A1220 |  | Cuerpo del dique - Relleno con material granular | 43d | 2023-05-06 | 2023-06-25 | A1210 SS+3d | 122d | 0d |
| A1230 |  | Perfilado de Talud del dique | 39d | 2023-05-13 | 2023-06-28 | A1220 SS+6d | 122d | 0d |
|  | 3 | **Geotextil** |  | 2023-05-17 | 2023-07-09 |  |  |  |
| A1260 |  | Instalación de Geotextil | 45d | 2023-05-17 | 2023-07-09 | A1230 SS+3d | 122d | 0d |
|  | 4 | **Colocación de Roca** |  | 2023-05-20 | 2023-07-28 |  |  |  |
| A1280 |  | Colocación de roca de uña | 43d | 2023-05-20 | 2023-07-11 | A1260 SS+3d | 122d | 0d |
| A1290 |  | Colocación de roca de talud | 52d | 2023-05-27 | 2023-07-28 | A1280 SS+6d | 122d | 0d |
|  | 5 | **Rellenos Complementarios** |  | 2023-07-08 | 2023-08-01 |  |  |  |
| A1240 |  | Relleno sin compactar | 18d | 2023-07-08 | 2023-08-01 | A1290 FF+1d | 149d | 0d |
| A1250 |  | Relleno afirmado | 6d | 2023-07-22 | 2023-08-01 | A1290 FF+1d | 149d | 0d |
|  | 5 | **Paquete 3** |  | 2023-07-01 | 2024-01-27 |  |  |  |
|  | 1 | **DI-PR-39-I (22 Espigones)** |  | 2023-07-11 | 2023-08-22 |  |  |  |
|  | 1 | **Excavaciones** |  | 2023-07-11 | 2023-08-11 |  |  |  |
| A1550 |  | Desbroce + Excavación bajo nivel freático | 25d | 2023-07-11 | 2023-08-11 | A1850 | 98d | 0d |
|  | 2 | **Colocación de Roca** |  | 2023-07-18 | 2023-08-22 |  |  |  |
| A1560 |  | Colocación de roca de uña | 23d | 2023-07-18 | 2023-08-16 | A1550 SS+6d, A1280 | 121d | 0d |
| A1570 |  | Colocación de roca de talud | 19d | 2023-07-31 | 2023-08-22 | A1560 SS+6d, A1290 | 122d | 1d |
|  | 2 | **DI-PR-41A-D** |  | 2023-07-01 | 2023-10-31 |  |  |  |
|  | 1 | **Diques Existentes** |  | 2023-07-01 | 2023-07-05 |  |  |  |
| A2840 |  | Extracción de Rocas Reutilizables | 3d | 2023-07-01 | 2023-07-05 | A1050 | 72d | 0d |
| A2850 |  | Remoción de dique existente | 3d | 2023-07-01 | 2023-07-05 | A2840 SS | 72d | 0d |
|  | 2 | **Excavaciones** |  | 2023-07-05 | 2023-07-11 |  |  |  |
| A1835 |  | Excavación - desbroce + cimentación + sobre excavación | 2d | 2023-07-05 | 2023-07-07 | A2850 | 72d | 0d |
| A1840 |  | Perfilado y conformación de plataforma de fundación | 3d | 2023-07-07 | 2023-07-11 | A1835 | 72d | 0d |
| A1850 |  | Excavación de uña | 3d | 2023-07-07 | 2023-07-11 | A1835 | 98d | 0d |

| ID | WBS | Activity | Duration | Start | Finish | Predecessors | Total float | Free float |
| --- | --- | --- | --- | --- | --- | --- | --- | --- |
|  | 3 | **Cimentación** |  | 2023-07-11 | 2023-09-13 |  |  |  |
| A2730 |  | Acero de Refuerzo | 31d | 2023-07-11 | 2023-08-18 | A1840 | 72d | 0d |
| A2740 |  | Encofrado | 26d | 2023-07-18 | 2023-08-19 | A2730 SS+6d | 72d | 0d |
| A2750 |  | Concreto | 34d | 2023-08-03 | 2023-09-13 | A2740 SS+12d | 72d | 0d |
|  | 4 | **Muro** |  | 2023-08-24 | 2023-10-12 |  |  |  |
| A2760 |  | Acero de Refuerzo | 25d | 2023-08-24 | 2023-09-23 | A2750 SS+18d | 72d | 0d |
| A2770 |  | Encofrado | 28d | 2023-09-01 | 2023-10-04 | A2760 SS+6d | 72d | 0d |
| A2780 |  | Concreto | 23d | 2023-09-15 | 2023-10-12 | A2770 SS+12d | 72d | 0d |
|  | 5 | **Rellenos** |  | 2023-10-26 | 2023-10-31 |  |  |  |
| A1860 |  | Relleno con material granular + material seleccionado | 2d | 2023-10-26 | 2023-10-28 | A1840, A2780 FS+12d | 72d | 0d |
| A1900 |  | Grava para drenaje | 2d | 2023-10-28 | 2023-10-31 | A1860 | 72d |  |
|  | 6 | **Colocación de Roca** |  | 2023-08-16 | 2023-08-25 |  |  |  |
| A2920 |  | Colocación de roca de uña | 2d | 2023-08-16 | 2023-08-18 | A1560 | 121d | 0d |
| A2930 |  | Colocación de roca de talud | 2d | 2023-08-23 | 2023-08-25 | A2920 SS+6d, A1570 | 121d | 23d |
|  | 3 | **DI-PR-41-D** |  | 2023-08-11 | 2023-09-30 |  |  |  |
|  | 1 | **Diques Existentes** |  | 2023-08-11 | 2023-08-13 |  |  |  |
| A2860 |  | Extracción de Rocas Reutilizables | 2d | 2023-08-11 | 2023-08-13 | A1550 | 98d | 0d |
| A2870 |  | Remoción de dique existente | 2d | 2023-08-11 | 2023-08-13 | A2860 SS | 98d | 0d |
|  | 2 | **Excavaciones** |  | 2023-08-14 | 2023-08-26 |  |  |  |
| A1955 |  | Excavación - desbroce + cimentación + sobre excavación | 5d | 2023-08-14 | 2023-08-19 | A2870 | 98d | 0d |
| A1960 |  | Perfilado y conformación de plataforma de fundación | 2d | 2023-08-19 | 2023-08-22 | A1840, A1955 | 98d | 0d |
| A1970 |  | Excavación de uña | 4d | 2023-08-22 | 2023-08-26 | A1960, A1850 | 98d | 0d |
|  | 3 | **Cuerpo del Dique** |  | 2023-08-25 | 2023-09-08 |  |  |  |
| A1980 |  | Cuerpo del dique - material granular + material seleccionado | 8d | 2023-08-25 | 2023-09-05 | A1970 SS+3d | 98d | 0d |
| A1990 |  | Perfilado de Talud del dique | 5d | 2023-09-02 | 2023-09-08 | A1980 SS+6d | 98d | 0d |

| ID | WBS | Activity | Duration | Start | Finish | Predecessors | Total float | Free float |
| --- | --- | --- | --- | --- | --- | --- | --- | --- |
|  | 4 | **Geotextil** |  | 2023-09-08 | 2023-09-21 |  |  |  |
| A2020 |  | Instalación de Geotextil | 11d | 2023-09-08 | 2023-09-21 | A1990 | 98d | 0d |
|  | 5 | **Colocación de Roca** |  | 2023-09-15 | 2023-09-30 |  |  |  |
| A2040 |  | Colocación de roca de uña | 6d | 2023-09-15 | 2023-09-22 | A2020 FF+1d, A2920 | 98d | 0d |
| A2050 |  | Colocación de roca de talud | 7d | 2023-09-22 | 2023-09-30 | A2040 SS+6d, A2930 | 98d |  |
|  | 4 | **DI-PD-18-I** |  | 2023-07-01 | 2023-09-03 |  |  |  |
|  | 1 | **Diques Existentes** |  | 2023-07-01 | 2023-07-07 |  |  |  |
| A2880 |  | Extracción de Rocas Reutilizables | 5d | 2023-07-01 | 2023-07-07 | A1050 | 0d |  |
| A2890 |  | Remoción de dique existente | 5d | 2023-07-01 | 2023-07-07 | A2880 SS | 0d |  |
|  | 2 | **Excavaciones** |  | 2023-07-07 | 2023-07-26 |  |  |  |
| A1315 |  | Excavación - desbroce + cimentación + sobre excavación | 15d | 2023-07-07 | 2023-07-25 | A2890 | 0d |  |
| A1320 |  | Perfilado y conformación de plataforma de fundación | 10d | 2023-07-14 | 2023-07-26 | A1315 SS+6d | 4d | 0d |
| A1330 |  | Excavación de uña | 7d | 2023-07-18 | 2023-07-26 | A1320 SS+3d | 4d | 0d |
|  | 3 | **Cuerpo del Dique** |  | 2023-07-21 | 2023-08-13 |  |  |  |
| A1340 |  | Cuerpo del dique - material granular + material seleccionado | 12d | 2023-07-21 | 2023-08-06 | A1330 SS+3d | 4d | 0d |
| A1350 |  | Perfilado de Talud del dique | 12d | 2023-07-31 | 2023-08-13 | A1340 SS+6d | 4d | 0d |
|  | 4 | **Geotextil** |  | 2023-08-03 | 2023-08-20 |  |  |  |
| A1380 |  | Instalación de Geotextil | 15d | 2023-08-03 | 2023-08-20 | A1350 SS+3d | 4d | 0d |
|  | 5 | **Colocación de Roca** |  | 2023-08-07 | 2023-09-03 |  |  |  |
| A1400 |  | Colocación de roca de uña | 15d | 2023-08-07 | 2023-08-24 | A1380 SS+3d | 4d | 0d |
| A1410 |  | Colocación de roca de talud | 17d | 2023-08-14 | 2023-09-03 | A1400 SS+6d | 8d | 0d |
|  | 5 | **DI-PR-19BIS-I** |  | 2023-07-25 | 2023-10-31 |  |  |  |
|  | 1 | **Excavaciones** |  | 2023-07-25 | 2023-09-10 |  |  |  |
| A1435 |  | Excavación - desbroce + cimentación + sobre excavación | 36d | 2023-07-25 | 2023-09-08 | A1315 | 0d |  |
| A1440 |  | Perfilado y conformación de plataforma de fundación | 31d | 2023-08-03 | 2023-09-09 | A1320, A1435 SS+6d | 4d | 0d |
| A1450 |  | Excavación de uña | 29d | 2023-08-07 | 2023-09-10 | A1330, A1440 SS+3d | 4d | 0d |

| ID | WBS | Activity | Duration | Start | Finish | Predecessors | Total float | Free float |
| --- | --- | --- | --- | --- | --- | --- | --- | --- |
|  | 2 | **Cuerpo del Dique** |  | 2023-08-10 | 2023-09-21 |  |  |  |
| A1460 |  | Cuerpo del dique - material granular + material seleccionado | 27d | 2023-08-10 | 2023-09-12 | A1450 SS+3d, A1340 | 4d | 0d |
| A1470 |  | Perfilado de Talud del dique | 29d | 2023-08-17 | 2023-09-21 | A1460 SS+6d, A1350 | 4d | 0d |
|  | 3 | **Geotextil** |  | 2023-08-21 | 2023-10-05 |  |  |  |
| A1500 |  | Instalación de Geotextil | 38d | 2023-08-21 | 2023-10-05 | A1380, A1470 SS+3d | 4d | 0d |
|  | 4 | **Colocación de Roca** |  | 2023-08-24 | 2023-10-31 |  |  |  |
| A1520 |  | Colocación de roca de uña | 55d | 2023-08-24 | 2023-10-28 | A1500 SS+3d, A1400 | 4d | 0d |
| A1530 |  | Colocación de roca de talud | 49d | 2023-09-04 | 2023-10-31 | A1410, A1520 SS+6d | 8d | 4d |
|  | 6 | **DI-PR-19-D** |  | 2023-09-08 | 2023-11-25 |  |  |  |
|  | 1 | **Excavaciones** |  | 2023-09-08 | 2023-10-13 |  |  |  |
| A2195 |  | Excavación - desbroce + cimentación + sobre excavación | 9d | 2023-09-08 | 2023-09-19 | A1435 | 0d |  |
| A2196 |  | Excavación - localizada / sobre excavación | 20d | 2023-09-19 | 2023-10-12 | A2195 | 0d |  |
| A2200 |  | Perfilado y conformación de plataforma de fundación | 15d | 2023-09-26 | 2023-10-13 | A1440, A2196 SS+6d | 14d | 0d |
| A2210 |  | Excavación de uña | 9d | 2023-09-29 | 2023-10-10 | A1450, A2200 SS+3d | 14d | 0d |
|  | 2 | **Cuerpo del Dique** |  | 2023-10-03 | 2023-10-25 |  |  |  |
| A2220 |  | Cuerpo del dique - material granular + material seleccionado | 13d | 2023-10-03 | 2023-10-18 | A2210 SS+3d, A1460 | 14d | 0d |
| A2230 |  | Perfilado de Talud del dique | 13d | 2023-10-10 | 2023-10-25 | A2220 SS+6d, A1470 | 14d | 0d |
|  | 3 | **Geotextil** |  | 2023-10-13 | 2023-10-31 |  |  |  |
| A2260 |  | Instalación de Geotextil | 15d | 2023-10-13 | 2023-10-31 | A1500, A2230 SS+3d | 14d | 10d |
|  | 4 | **Colocación de Roca** |  | 2023-10-28 | 2023-11-25 |  |  |  |
| A2280 |  | Colocación de roca de uña | 13d | 2023-10-28 | 2023-11-14 | A2260 SS+3d, A1520 | 4d | 0d |
| A2290 |  | Colocación de roca de talud | 17d | 2023-11-06 | 2023-11-25 | A1530, A2280 SS+6d | 4d | 1d |
|  | 7 | **DI-PR-20-D** |  | 2023-10-12 | 2024-01-20 |  |  |  |
|  | 1 | **Diques Existentes** |  | 2023-10-12 | 2023-10-18 |  |  |  |
| A2900 |  | Extracción de Rocas Reutilizables | 5d | 2023-10-12 | 2023-10-18 | A2196 | 0d |  |
| A2910 |  | Remoción de dique existente | 5d | 2023-10-12 | 2023-10-18 | A2900 SS | 0d |  |

| ID | WBS | Activity | Duration | Start | Finish | Predecessors | Total float | Free float |
| --- | --- | --- | --- | --- | --- | --- | --- | --- |
|  | 2 | **Excavaciones** |  | 2023-10-18 | 2023-12-05 |  |  |  |
| A2075 |  | Excavación - desbroce + cimentación | 28d | 2023-10-18 | 2023-11-21 | A2910 | 0d |  |
| A2076 |  | Excavación - localizada / sobre excavación | 35d | 2023-10-21 | 2023-12-02 | A2075 SS+3d, A2196 | 3d | 0d |
| A2080 |  | Perfilado y conformación de plataforma de fundación | 31d | 2023-10-28 | 2023-12-05 | A2200, A2076 SS+6d | 3d | 0d |
| A2090 |  | Excavación de uña | 26d | 2023-11-02 | 2023-12-02 | A2210, A2080 SS+3d | 3d | 0d |
|  | 3 | **Cuerpo del Dique** |  | 2023-11-06 | 2023-12-17 |  |  |  |
| A2100 |  | Cuerpo del dique - material granular + material seleccionado | 29d | 2023-11-06 | 2023-12-10 | A2090 SS+3d, A2220 | 3d | 0d |
| A2110 |  | Perfilado de Talud del dique | 29d | 2023-11-13 | 2023-12-17 | A2100 SS+6d, A2230 | 3d | 0d |
|  | 4 | **Geotextil** |  | 2023-11-16 | 2023-12-31 |  |  |  |
| A2140 |  | Instalación de Geotextil | 37d | 2023-11-16 | 2023-12-31 | A2260, A2110 SS+3d | 3d | 0d |
|  | 5 | **Colocación de Roca** |  | 2023-11-20 | 2024-01-20 |  |  |  |
| A2160 |  | Colocación de roca de uña | 45d | 2023-11-20 | 2024-01-14 | A2140 SS+3d, A2280 | 3d | 0d |
| A2170 |  | Colocación de roca de talud | 44d | 2023-11-27 | 2024-01-20 | A2290, A2160 SS+6d | 3d | 0d |
|  | 8 | **DI-PD-44-D** |  | 2023-11-21 | 2024-01-21 |  |  |  |
|  | 1 | **Excavaciones** |  | 2023-11-21 | 2023-12-21 |  |  |  |
| A1715 |  | Excavación - desbroce + cimentación + sobre excavación | 9d | 2023-11-21 | 2023-12-01 | A2075 | 0d |  |
| A1720 |  | Perfilado y conformación de plataforma de fundación | 7d | 2023-11-28 | 2023-12-06 | A1715 SS+6d | 0d |  |
| A1730 |  | Excavación de uña | 16d | 2023-12-01 | 2023-12-21 | A1720 SS+3d | 0d |  |
|  | 2 | **Cuerpo del Dique** |  | 2023-12-05 | 2023-12-27 |  |  |  |
| A1740 |  | Cuerpo del dique - material granular + material seleccionado | 16d | 2023-12-05 | 2023-12-24 | A1730 SS+3d | 0d |  |
| A1750 |  | Perfilado de Talud del dique | 11d | 2023-12-13 | 2023-12-27 | A1740 SS+6d | 0d |  |
|  | 3 | **Geotextil** |  | 2023-12-16 | 2024-01-03 |  |  |  |
| A1780 |  | Instalación de Geotextil | 13d | 2023-12-16 | 2024-01-03 | A1750 SS+3d | 0d |  |
|  | 4 | **Colocación de Roca** |  | 2023-12-20 | 2024-01-21 |  |  |  |
| A1800 |  | Colocación de roca de uña | 16d | 2023-12-20 | 2024-01-10 | A1780 SS+3d | 0d |  |
| A1810 |  | Colocación de roca de talud | 20d | 2023-12-28 | 2024-01-21 | A1800 SS+6d | 0d |  |

| ID | WBS | Activity | Duration | Start | Finish | Predecessors | Total float | Free float |
| --- | --- | --- | --- | --- | --- | --- | --- | --- |
|  | 9 | **DE-PR-45-D** |  | 2023-12-01 | 2024-01-27 |  |  |  |
|  | 1 | **Excavaciones** |  | 2023-12-01 | 2023-12-28 |  |  |  |
| A1595 |  | Excavación - desbroce + cimentación + localizada | 3d | 2023-12-01 | 2023-12-05 | A1715 | 43d |  |
| A1600 |  | Perfilado y conformación de plataforma de fundación | 3d | 2023-12-06 | 2023-12-10 | A1720 | 25d | 9d |
| A1610 |  | Excavación de uña | 5d | 2023-12-21 | 2023-12-28 | A1730, A1600 SS+3d | 16d | 0d |
|  | 2 | **Cuerpo del Dique** |  | 2023-12-26 | 2024-01-07 |  |  |  |
| A1620 |  | Cuerpo del dique - material granular + material seleccionado | 5d | 2023-12-26 | 2023-12-31 | A1610 SS+3d, A1740 | 16d | 0d |
| A1630 |  | Perfilado de Talud del dique | 5d | 2024-01-02 | 2024-01-07 | A1620, A1750 | 17d |  |
|  | 3 | **Geotextil** |  | 2024-01-03 | 2024-01-12 |  |  |  |
| A1660 |  | Instalación de Geotextil - uña | 8d | 2024-01-03 | 2024-01-12 | A1610 SS+3d, A1780 | 12d | 3d |
|  | 4 | **Colocación de Roca** |  | 2024-01-10 | 2024-01-27 |  |  |  |
| A1680 |  | Colocación de roca de uña | 6d | 2024-01-10 | 2024-01-17 | A1660 SS+3d, A1800 | 9d |  |
| A1690 |  | Colocación de roca de talud | 5d | 2024-01-22 | 2024-01-27 | A1810, A1800 SS+6d | 0d |  |
|  | 10 | **Rellenos Complementarios** |  | 2023-10-30 | 2024-01-24 |  |  |  |
| A2000 |  | Relleno sin compactar | 70d | 2023-10-30 | 2024-01-24 | A2170 FF+3d | 3d |  |
| A2310 |  | Grava para drenaje | 51d | 2023-11-07 | 2024-01-09 | A1620 FF+6d | 16d |  |
| A2010 |  | Relleno afirmado | 24d | 2023-12-26 | 2024-01-24 | A2170 FF+3d | 3d |  |
|  | 6 | **Obras Civiles** |  | 2023-04-21 | 2024-01-25 |  |  |  |
|  | 1 | **Paquete 2** |  | 2023-04-21 | 2023-06-24 |  |  |  |
| A2300 |  | Estructuras de cruce - 02 und | 30d | 2023-04-21 | 2023-05-27 | A1030 | 178d | 0d |
| A2320 |  | Interferencias - diques paquete 02 | 24d | 2023-05-27 | 2023-06-24 | A2300 | 178d | 29d |
|  | 2 | **Paquete 3** |  | 2023-07-01 | 2024-01-25 |  |  |  |
| A2720 |  | Estructuras de cruce - 11 und | 165d | 2023-07-01 | 2024-01-18 | A1050 | 2d | 0d |
| A2830 |  | Interferencias - diques paquete 03 | 48d | 2023-11-27 | 2024-01-25 | A2720 FF+6d | 2d |  |

| ID | WBS | Activity | Duration | Start | Finish | Predecessors | Total float |
| --- | --- | --- | --- | --- | --- | --- | --- |
|  | 7 | **Accesos** |  | 2023-12-11 | 2024-01-24 |  |  |
| A2660 |  | Losa de concreto para accesos de mantenimiento - Paquete 03 (06 unidades) | 36d | 2023-12-11 | 2024-01-24 | A2170 FF+3d | 3d |
